# Tiburon II replacement.mpp

Schedule from MS Project, 2006-12-15 to 2008-07-02, costs in $.
Tiburon Replacement
MBARI

## Calendars

- Standard: Mon-Fri 08:00-12:00, 13:00-17:00; Sat-Sun off. Exceptions (off unless hours are given): 2007-01-29 to 2007-02-02, 2007-12-24 to 2007-12-28.

## Resources

| Resource | Group | Rate |
| --- | --- | --- |
| Mike Risi | Support Engineering |  |
| Mark Brown | Support Engineering |  |
| Ed Mellinger | Engineering |  |
| Rich Schramm | Support Engineering |  |
| Larry Bird | Engineering |  |
| Bob Herlien | Engineering |  |
| Machinist | Engineering |  |
| Dale Graves | Marine Operations |  |
| Brett Hobson | Engineering |  |
| Buck Reynolds | Pilots |  |
| Prizm slip ring |  | 40000 |
| Tiburon II vehicle |  |  |
| WF Crane replacement |  | 160875 |
| Shipping |  | 50000 |
| CTD Instrument |  | 16125 |
| IVIEW computer hardware |  | 3000 |
| Depth sensor instrument |  | 10000 |
| Travel |  | 28000 |
| General Supplies |  | 10000 |
| Nav/Logging computer hardware |  | 9600 |
| Science interface controller |  | 48088 |
| VB Tanks |  | 5000 |
| PDU service installation |  |  |
| CT/Lift winch |  |  |
| Pilots | Pilots |  |
| Ships crew | Crew |  |

## Schedule

| ID | WBS | Task | Type | Duration | Start | Finish | Predecessors | Total slack | Constraint | Resources | Work |
| --- | --- | --- | --- | --- | --- | --- | --- | --- | --- | --- | --- |
| 1 | 1 | **Vehicle design and development (SMDH)** |  | 275d | 2006-12-15 | 2008-01-17 |  | 0d |  |  | 988.4h |
| 2 | 1.1 | **Requirements Document & Contract** |  | 55d | 2006-12-15 | 2007-03-08 |  | 0d |  |  | 268.4h |
| 3 | 1.1.1 | Rev 0.0 development |  | 15d | 2006-12-15 | 2007-01-04 |  | 0d | must finish on 2007-01-04 | Dale Graves [50%] | 60h |
| 4 | 1.1.2 | SMDH's review and comment |  | 15d | 2007-01-05 | 2007-01-25 | 3 | 0d |  |  |  |
| 5 | 1.1.3 | Reply to SMDH questions |  | 15d | 2007-01-05 | 2007-01-25 | 4FF | 0d |  | Brett Hobson [10%]; Ed Mellinger [20%]; Dale Graves [25%] | 66h |
| 6 | 1.1.4 | Review and incorporate SMDH comments |  | 2d | 2007-01-26 | 2007-02-05 | 5 | 0d |  | Mike Risi [50%]; Ed Mellinger [50%]; Dale Graves; Brett Hobson [50%] | 40h |
| 7 | 1.1.5 | Prep for internal requirements review |  | 2d | 2007-02-06 | 2007-02-07 | 6 | 0d |  | Dale Graves | 16h |
| 8 | 1.1.6 | Internal requirements review |  | 1d | 2007-02-08 | 2007-02-08 | 7 | 0d |  | Brett Hobson [20%]; Mike Risi [20%]; Mark Brown [20%]; Dale Graves [20%] | 6.4h |
| 9 | 1.1.7 | RFP Rev 1.0 development |  | 5d | 2007-02-09 | 2007-02-15 | 8 | 0d |  | Dale Graves | 40h |
| 10 | 1.1.8 | SMDH response to RFP |  | 10d | 2007-02-16 | 2007-03-01 | 9 | 0d |  |  |  |
| 11 | 1.1.9 | Negotiate Contract Terms |  | 5d | 2007-03-02 | 2007-03-08 | 10 | 0d |  | Dale Graves | 40h |
| 12 | 1.1.10 | Contract Completed | milestone | 0d | 2007-03-08 | 2007-03-08 | 11 | 0d |  |  |  |
| 13 | 1.2 | **Preliminary Design Reviews** |  | 40d | 2007-03-09 | 2007-05-04 | 2 | 0d |  |  | 232h |
| 14 | 1.2.1 | Preperation for PDR |  | 35d | 2007-03-09 | 2007-04-26 |  | 0d | as late as possible | Brett Hobson [10%]; Mark Brown [10%]; Mike Risi [10%]; Dale Graves [10%] | 112h |
| 15 | 1.2.2 | PDR@SMDH |  | 4d | 2007-04-27 | 2007-05-02 | 14 | 0d | as late as possible | Brett Hobson; Mike Risi; Dale Graves | 96h |
| 16 | 1.2.3 | PDR Review@MBARI |  | 1d | 2007-05-03 | 2007-05-03 | 15 | 0d | as late as possible | Brett Hobson; Mike Risi; Dale Graves | 24h |
| 17 | 1.2.4 | PDR Completed | milestone | 0d | 2007-05-04 | 2007-05-04 | 16 | 0d | as late as possible |  |  |
| 18 | 1.3 | **Critical Design Reviews** |  | 40d | 2007-05-04 | 2007-06-29 | 13 | 0d |  |  | 232h |
| 19 | 1.3.1 | Preperation for CDR |  | 35d | 2007-05-04 | 2007-06-21 |  | 0d |  | Dale Graves [10%]; Mike Risi [10%]; Mark Brown [10%]; Brett Hobson [10%] | 112h |
| 20 | 1.3.2 | CDR@SMDH |  | 4d | 2007-06-22 | 2007-06-27 | 19 | 0d | as late as possible | Brett Hobson; Mike Risi; Dale Graves | 96h |
| 21 | 1.3.3 | CDR Review@MBARI |  | 1d | 2007-06-28 | 2007-06-28 | 20 | 0d | as late as possible | Brett Hobson; Mike Risi; Dale Graves | 24h |
| 22 | 1.3.4 | CDR Completed | milestone | 0d | 2007-06-29 | 2007-06-29 | 21 | 0d | as late as possible |  |  |
| 23 | 1.4 | **Vehicle in Manufacturing** |  | 100d | 2007-06-29 | 2007-11-16 | 18 | 0d |  |  |  |
| 24 | 1.4.1 | Manufacturing |  | 100d | 2007-06-29 | 2007-11-15 |  | 0d | as late as possible |  |  |
| 25 | 1.4.2 | Manufacturing complete | milestone | 0d | 2007-11-16 | 2007-11-16 |  | 0d | as late as possible |  |  |

| ID | WBS | Task | Type | Duration | Start | Finish | Predecessors | Total slack | Free slack | Constraint | Resources | Work | Cost |
| --- | --- | --- | --- | --- | --- | --- | --- | --- | --- | --- | --- | --- | --- |
| 26 | 1.5 | **Factory Acceptance Tests** |  | 9d | 2007-11-16 | 2007-11-29 | 23 | 0d |  |  |  | 256h |  |
| 27 | 1.5.1 | Develop FAT test plan |  | 5d | 2007-11-16 | 2007-11-22 |  | 0d |  | as late as possible | Mike Risi; Brett Hobson; Dale Graves; Mark Brown | 160h |  |
| 28 | 1.5.2 | Perform test at SMDH facility |  | 4d | 2007-11-23 | 2007-11-28 | 27 | 0d |  | as late as possible | Mike Risi; Brett Hobson; Mark Brown | 96h |  |
| 29 | 1.5.3 | FAT completed | milestone | 0d | 2007-11-29 | 2007-11-29 | 28 | 0d |  | as late as possible |  |  |  |
| 30 | 1.6 | **Vehicle Shipping** |  | 31d | 2007-11-29 | 2008-01-17 | 26 | 0d |  |  |  |  |  |
| 31 | 1.6.1 | Prepare for shipping |  | 6d | 2007-11-29 | 2007-12-06 |  | 0d |  |  |  |  |  |
| 32 | 1.6.2 | In shipping |  | 25d | 2007-12-07 | 2008-01-17 | 31 | 0d |  |  |  |  |  |
| 33 | 1.6.3 | Arrives at MBARI | milestone | 0d | 2008-01-17 | 2008-01-17 | 32 | 0d |  |  |  |  |  |
| 34 | 2 | **MBARI design and development** |  | 305d? | 2006-12-15 | 2008-02-28 |  | 88.67d |  |  |  | 1449.33h | 160,875 |
| 35 | 2.1 | **NAVPROC, DataManager upgrades** |  | 226d | 2007-01-08 | 2007-11-26 |  | 151.67d |  |  |  | 868h |  |
| 36 | 2.1.1 | Requirements document |  | 2d | 2007-01-08 | 2007-01-09 |  | 348.67d | 0d | start no earlier than 2007-01-08 | Mike Risi | 16h |  |
| 37 | 2.1.2 | Setup and install hardware |  | 3d | 2007-01-10 | 2007-01-12 | 36 | 348.67d | 0d |  | Dale Graves [50%]; Mike Risi | 36h |  |
| 38 | 2.1.3 | Software development |  | 38d | 2007-01-15 | 2007-03-14 | 37 | 328.01d | 0d |  | Mike Risi [50%] | 152h |  |
| 39 | 2.1.4 | Software testing |  | 6.67d | 2007-03-15 | 2007-03-23 | 38 | 328.01d |  |  | Mike Risi [75%] | 40h |  |
| 40 | 2.1.5 | Integrate with SMDH system |  | 5d | 2007-08-14 | 2007-08-20 | 51 | 151.67d | 0d |  | Mike Risi | 40h |  |
| 41 | 2.1.6 | Data logging |  | 30d | 2007-10-16 | 2007-11-26 | 43, 40 | 151.67d |  |  | Rich Schramm | 240h |  |
| 42 | 2.1.7 | **Integrate Overlay system with SMDH** |  | 48d | 2007-08-21 | 2007-10-25 | 40 | 151.67d |  |  |  | 64h |  |
| 43 | 2.1.7.1 | Purchase new overlay system |  | 8w | 2007-08-21 | 2007-10-15 |  | 151.67d | 0d |  |  |  |  |
| 44 | 2.1.7.2 | Integrate with Tiburon I |  | 4d | 2007-10-16 | 2007-10-19 | 43 | 173.67d | 0d |  | Mike Risi | 32h |  |
| 45 | 2.1.7.3 | Integrate with Tiburon II |  | 4d | 2007-10-22 | 2007-10-25 | 44 | 173.67d |  |  | Mike Risi | 32h |  |
| 46 | 2.1.8 | **IVEW Module** |  | 35d | 2007-06-26 | 2007-08-13 |  | 151.67d |  | start no earlier than 2007-06-26 |  | 280h |  |
| 47 | 2.1.8.1 | IVEW requirements document |  | 2d | 2007-06-26 | 2007-06-27 |  | 151.67d | 0d |  | Mike Risi | 16h |  |
| 48 | 2.1.8.2 | Develop software module |  | 23d | 2007-06-28 | 2007-07-30 | 47 | 151.67d | 0d |  | Mike Risi | 184h |  |
| 49 | 2.1.8.3 | Software / hardware testing |  | 5d | 2007-07-31 | 2007-08-06 | 48 | 151.67d | 0d |  | Mike Risi | 40h |  |
| 50 | 2.1.8.4 | Integrate with SMDH system |  | 5d | 2007-08-07 | 2007-08-13 | 49 | 151.67d | 0d |  | Mike Risi | 40h |  |
| 51 | 2.1.8.5 | IVIEW complete | milestone | 0d | 2007-08-13 | 2007-08-13 | 50 | 151.67d | 0d |  |  |  |  |

| ID | WBS | Task | Duration | Start | Finish | Predecessors | Total slack | Free slack | Constraint | Resources | Work | Cost |
| --- | --- | --- | --- | --- | --- | --- | --- | --- | --- | --- | --- | --- |
| 52 | 2.2 | **Instrument Sub Frame** | 50d | 2007-06-29 | 2007-09-06 | 22 | 174.67d | 0d |  |  | 240h |  |
| 53 | 2.2.1 | Requirements document | 2d | 2007-06-29 | 2007-07-02 |  | 179.67d | 0d |  | Dale Graves | 16h |  |
| 54 | 2.2.2 | Frame Design | 10d | 2007-07-03 | 2007-07-23 | 53 | 174.67d | 0d |  | Dale Graves | 80h |  |
| 55 | 2.2.3 | Bracket Design | 10d | 2007-07-24 | 2007-08-06 | 54 | 174.67d | 0d |  | Dale Graves | 80h |  |
| 56 | 2.2.4 | **Frame Fabrication** | 23d | 2007-08-07 | 2007-09-06 | 55 | 174.67d |  |  |  | 64h |  |
| 57 | 2.2.4.1 | Machine shop lead time | 2w | 2007-08-07 | 2007-08-20 |  | 174.67d | 0d |  |  |  |  |
| 58 | 2.2.4.2 | Fabrication & welding | 8d | 2007-08-21 | 2007-08-30 | 57 | 174.67d | 0d |  | Machinist | 64h |  |
| 59 | 2.2.4.3 | Plating | 5d | 2007-08-31 | 2007-09-06 | 58 | 174.67d |  |  |  |  |  |
| 60 | 2.3 | **VB system upgrades** | 34d | 2007-09-07 | 2007-10-24 | 52 | 174.67d |  |  |  | 152h |  |
| 61 | 2.3.1 | Requirements document | 2d | 2007-09-07 | 2007-09-10 |  | 174.67d | 0d |  | Dale Graves | 16h |  |
| 62 | 2.3.2 | Design VB tanks | 10d | 2007-09-11 | 2007-09-24 | 61 | 174.67d | 0d |  | Dale Graves | 80h |  |
| 63 | 2.3.3 | **Fabricate VB tanks** | 22d | 2007-09-25 | 2007-10-24 | 62 | 174.67d |  |  |  | 56h |  |
| 64 | 2.3.3.1 | Machine shop lead time | 2w | 2007-09-25 | 2007-10-08 |  | 174.67d | 0d |  |  |  |  |
| 65 | 2.3.3.2 | Fabrication | 7d | 2007-10-09 | 2007-10-17 | 64 | 174.67d | 0d |  | Machinist | 56h |  |
| 66 | 2.3.3.3 | Plating | 5d | 2007-10-18 | 2007-10-24 | 65 | 174.67d |  |  |  |  |  |
| 67 | 2.4 | **Ships systems** | 305d? | 2006-12-15 | 2008-02-28 |  | 88.67d |  |  |  | 69.33h | 160,875 |
| 68 | 2.4.1 | **Control room layout** | 1d? | 2006-12-15 | 2006-12-15 |  | 392.67d |  |  |  |  |  |
| 69 | 2.4.1.1 | Block diagram of topside power system | 1d? | 2006-12-15 | 2006-12-15 |  | 392.67d |  |  |  |  |  |
| 70 | 2.4.1.2 | Floor layout of control room | 1d? | 2006-12-15 | 2006-12-15 |  | 392.67d |  |  |  |  |  |
| 71 | 2.4.1.3 | Determine PDU placement | 1d? | 2006-12-15 | 2006-12-15 |  | 392.67d |  |  |  |  |  |
| 72 | 2.4.1.4 | RFQ for 400amp circuit run | 1d? | 2006-12-15 | 2006-12-15 |  | 392.67d |  |  |  |  |  |
| 73 | 2.4.2 | **Vehicle handling system** | 287d | 2007-01-10 | 2008-02-28 |  | 88.67d |  |  |  | 69.33h | 160,875 |
| 74 | 2.4.2.1 | Log acceleration data | 103d | 2007-01-10 | 2007-06-08 |  | 221.67d | 0d | start no earlier than 2007-01-10 |  |  |  |
| 75 | 2.4.2.2 | Crane upgrade decision | 1d | 2007-06-11 | 2007-06-11 | 74 | 221.67d | 0d |  | Mark Brown [50%]; Brett Hobson [50%]; Dale Graves [50%] | 9.33h |  |
| 76 | 2.4.2.3 | Identify new crane | 10d | 2007-06-12 | 2007-06-25 | 75 | 221.67d | 0d |  | Brett Hobson [25%]; Larry Bird [25%] | 40h |  |
| 77 | 2.4.2.4 | Purchase & delivery of new crane | 8w | 2008-01-04 | 2008-02-28 | 76 | 88.67d |  | start no earlier than 2008-01-04 | WF Crane replacement |  | 160,875 |
| 78 | 2.4.2.5 | Identify new CT/Lift winch for crane | 10d | 2007-06-12 | 2007-06-25 | 76SS | 221.67d | 133d |  | Brett Hobson [25%] | 20h |  |
| 79 | 2.4.2.6 | Purchase CT/Lift winch | 8w | 2008-01-04 | 2008-02-28 | 78 | 88.67d |  | start no earlier than 2008-01-04 | CT/Lift winch |  |  |
| 80 | 2.5 | 2008 Project proposal development | 13.33d | 2007-06-01 | 2007-06-20 |  | 265.34d |  | start no earlier than 2007-06-01 | Dale Graves [75%]; Mike Risi [20%]; Brett Hobson [20%] | 120h |  |

| ID | WBS | Task | Type | Duration | Start | Finish | Predecessors | Total slack | Constraint | Resources | Work |
| --- | --- | --- | --- | --- | --- | --- | --- | --- | --- | --- | --- |
| 81 | 3 | **Integration & testing** |  | 118.67d? | 2008-01-18 | 2008-07-02 |  | 0d |  |  | 242.06h |
| 82 | 3.1 | **ROV Equipment Integeration & shore testing** |  | 105.67d | 2008-01-18 | 2008-06-13 | 33 | 0d |  |  | 106.06h |
| 83 | 3.1.1 | Installation and test plan |  | 5d | 2008-01-18 | 2008-01-24 |  | 0d |  | Dale Graves | 40h |
| 84 | 3.1.2 | Instrument Frame Integration |  | 12.67d | 2008-01-25 | 2008-02-12 | 83 | 0d | as late as possible | Dale Graves [50%]; Larry Bird [50%] | 66.06h |
| 85 | 3.1.3 | Instrument integration and testing |  | 20d | 2008-02-12 | 2008-03-11 | 84 | 0d | as late as possible |  |  |
| 86 | 3.1.4 | External VB tank integration |  | 5d | 2008-03-11 | 2008-03-18 | 85 | 0d | as late as possible |  |  |
| 87 | 3.1.5 | Test tank & ROV lab test setup |  | 20d | 2008-03-18 | 2008-04-15 | 86 | 0d | as late as possible |  |  |
| 88 | 3.1.6 | Tool sled integration |  | 3d | 2008-04-15 | 2008-04-18 | 87 | 0d | as late as possible |  |  |
| 89 | 3.1.7 | Equipment integration complete | milestone | 0d | 2008-04-18 | 2008-04-18 | 88 | 0d | as late as possible |  |  |
| 90 | 3.1.8 | Test tank testing |  | 40d | 2008-04-18 | 2008-06-13 | 89 | 0d | as late as possible |  |  |
| 91 | 3.2 | **Ship Integration** |  | 10d? | 2008-06-13 | 2008-06-27 | 90 | 0d |  |  | 40h |
| 92 | 3.2.1 | Installation and test plan |  | 5d | 2008-06-13 | 2008-06-20 |  | 0d |  | Dale Graves | 40h |
| 93 | 3.2.2 | **New crane integration** |  | 1d? | 2008-06-20 | 2008-06-23 | 92 | 0d |  |  |  |
| 94 | 3.2.2.1 | Install new crane |  | 1d? | 2008-06-20 | 2008-06-23 |  | 0d |  |  |  |
| 95 | 3.2.2.2 | Load test crane |  | 1d? | 2008-06-20 | 2008-06-23 |  | 7d |  |  |  |
| 96 | 3.2.3 | **Power systems integration** |  | 1d? | 2008-06-23 | 2008-06-24 | 94 | 0d |  |  |  |
| 97 | 3.2.3.1 | Run wire for new PDU HPU power (400amp load) |  | 1d? | 2008-06-23 | 2008-06-24 |  | 0d |  |  |  |
| 98 | 3.2.3.2 | Install new PDU and transformers |  | 1d? | 2008-06-23 | 2008-06-24 |  | 6d |  |  |  |
| 99 | 3.2.4 | **Control room integration** |  | 1d? | 2008-06-24 | 2008-06-25 | 97 | 0d |  |  |  |
| 100 | 3.2.4.1 | Install video switcher |  | 1d? | 2008-06-24 | 2008-06-25 |  | 0d |  |  |  |
| 101 | 3.2.4.2 | Install SMDH network hardware and GUI |  | 1d? | 2008-06-24 | 2008-06-25 |  | 5d |  |  |  |
| 102 | 3.2.5 | **Umbilical integration** |  | 2d? | 2008-06-25 | 2008-06-27 | 100 | 0d |  |  |  |
| 103 | 3.2.5.1 | Remove old and install new umbilical on drum |  | 1d? | 2008-06-25 | 2008-06-26 |  | 4d |  |  |  |
| 104 | 3.2.5.2 | Terminate umbilical |  | 1d? | 2008-06-25 | 2008-06-26 |  | 4d |  |  |  |
| 105 | 3.2.5.3 | Slip ring integration |  | 2d | 2008-06-25 | 2008-06-27 |  | 0d | as late as possible |  |  |
| 106 | 3.2.6 | Ship Integration complete | milestone | 0d | 2008-06-27 | 2008-06-27 | 105 | 0d | as late as possible |  |  |

| ID | WBS | Task | Type | Duration | Start | Finish | Predecessors | Total slack | Resources | Work |
| --- | --- | --- | --- | --- | --- | --- | --- | --- | --- | --- |
| 107 | 3.3 | **Sea Trials** |  | 3d | 2008-06-27 | 2008-07-02 | 106 | 0d |  | 96h |
| 108 | 3.3.1 | Develop Sea Trials test plan |  | 2d | 2008-06-27 | 2008-07-01 |  | 0d | Mike Risi; Brett Hobson; Dale Graves; Mark Brown | 64h |
| 109 | 3.3.2 | At sea testing |  | 1d | 2008-07-01 | 2008-07-02 | 108 | 0d | Brett Hobson; Dale Graves; Mark Brown; Mike Risi | 32h |
| 110 | 3.3.3 | Sea Trials completed / project completed | milestone | 0d | 2008-07-02 | 2008-07-02 | 109 | 0d |  |  |
